# VDC Cernknica G+O+I

Schedule from MS Project, 2004-09-17 to 2005-08-08, status date 2007-02-09, 9.5 hours a day, costs in SIT, A marks actual dates.
ENERGOPLAN D.D.

## Calendars

- Standard: Mon-Fri 07:00-10:00, 10:30-17:00; Sat 07:00-10:00, 10:30-15:00; Sun off. Exceptions (off unless hours are given): 2004-10-02 08:00-12:00, 13:00-17:00, 2004-10-09 08:00-12:00, 13:00-17:00, 2004-10-16 08:00-12:00, 13:00-17:00, 2004-10-23 08:00-12:00, 13:00-17:00, 2004-11-01, 2004-11-06 08:00-12:00, 13:00-17:00, 2004-11-13 08:00-12:00, 13:00-17:00, 2004-11-20 08:00-12:00, 13:00-17:00, 2004-11-27 08:00-12:00, 13:00-17:00, 2004-12-04 08:00-12:00, 13:00-17:00, 2004-12-11 08:00-12:00, 13:00-17:00, 2004-12-18 08:00-12:00, 13:00-17:00, 2004-12-24, 2004-12-27 to 2004-12-31, 2005-01-08 08:00-12:00, 13:00-17:00, 2005-01-15 08:00-12:00, 13:00-17:00, 2005-01-22 08:00-12:00, 13:00-17:00, 2005-01-29 08:00-12:00, 13:00-17:00, 2005-02-05 08:00-12:00, 13:00-17:00, 2005-02-08, 2005-02-12 08:00-12:00, 13:00-17:00, 2005-02-19 08:00-12:00, 13:00-17:00, 2005-02-26 08:00-12:00, 13:00-17:00, 2005-03-05 08:00-12:00, 13:00-17:00, 2005-03-12 08:00-12:00, 13:00-17:00, 2005-03-19 08:00-12:00, 13:00-17:00, 2005-03-26 08:00-12:00, 13:00-17:00, 2005-04-02 08:00-12:00, 13:00-17:00, 2005-04-09 08:00-12:00, 13:00-17:00, 2005-04-16 08:00-12:00, 13:00-17:00, 2005-04-23 08:00-12:00, 13:00-17:00, 2005-04-27 to 2005-04-29, 2005-05-07 08:00-12:00, 13:00-17:00, 2005-05-14 08:00-12:00, 13:00-17:00, 2005-05-21 08:00-12:00, 13:00-17:00, 2005-05-28 08:00-12:00, 13:00-17:00, 2005-06-04 08:00-12:00, 13:00-17:00, 2005-06-11 08:00-12:00, 13:00-17:00, 2005-06-18 08:00-12:00, 13:00-17:00, 2005-06-25, 2005-07-02 08:00-12:00, 13:00-17:00, 2005-07-09 08:00-12:00, 13:00-17:00, 2005-07-16 08:00-12:00, 13:00-17:00, 2005-07-23 08:00-12:00, 13:00-17:00, 2005-07-30 08:00-12:00, 13:00-17:00, 2005-08-06 to 2005-08-07 08:00-12:00, 13:00-17:00.

## Resources

| Resource | Rate |
| --- | --- |
| Delavec | 1380 |
| železokrivec | 1757.5 |
| tesar | 1380 |

## Schedule

| ID | WBS | Task | Duration | Start | Finish | Predecessors | Complete | Baseline start | Baseline finish | Baseline duration | Constraint | Resources | Work | Actual work | Cost | Baseline cost | Actual cost |
| --- | --- | --- | --- | --- | --- | --- | --- | --- | --- | --- | --- | --- | --- | --- | --- | --- | --- |
| 1 | 1 | **Pripravljalna dela** | 27.11d | 2004-09-17 A | 2004-10-19 A |  | 100% | 2004-09-21 | 2004-09-29 | 7d |  |  | 460h | 460h | 1,117,374.15 | 71,249.99 | 1,117,374.15 |
| 2 | 1.1 | Zakoličba, postavitev gradbišča | 16.63d | 2004-09-17 A | 2004-10-19 A |  | 100% | 2004-09-21 | 2004-09-29 | 7d | start no earlier than 2004-09-17 | Delavec [578.9%] | 460h | 460h | 1,117,374.15 | 71,249.99 | 1,117,374.15 |
| 3 | 2 | **GRADBENA DELA** | 205.89d | 2004-09-23 A | 2005-06-09 A |  | 100% | 2004-09-25 | 2005-05-18 | 184.97d |  |  | 19782.5h | 19782.5h | 86,244,462.62 | 80,295,142.35 | 86,244,462.62 |
| 4 | 2.1 | **Zemeljska dela** | 66d | 2004-09-23 A | 2004-12-11 A |  | 100% | 2004-09-25 | 2004-11-09 | 35.84d |  |  |  |  | 1,609,020.66 | 2,618,612.44 | 1,609,020.66 |
| 5 | 2.1.1 | Odriv humusa | 5.79d | 2004-09-23 A | 2004-09-29 A | 2SS+4d | 100% | 2004-09-25 | 2004-09-28 | 2.43d | start no earlier than 2004-09-23 |  |  |  | 68,309.76 | 322,700.01 | 68,309.76 |
| 6 | 2.1.2 | Široki izkop | 8.84d | 2004-09-27 A | 2004-10-06 A | 5 | 100% | 2004-09-28 | 2004-10-07 | 7.24d | start no earlier than 2004-09-27 |  |  |  | 523,935 | 1,271,086.76 | 523,935 |
| 7 | 2.1.3 | Zasip temeljev | 31.05d | 2004-11-05 A | 2004-12-11 A | 11SS+3d | 100% | 2004-10-30 | 2004-11-09 | 6.53d | start no earlier than 2004-11-05 |  |  |  | 1,016,775.9 | 1,024,825.68 | 1,016,775.9 |
| 8 | 2.2 | **Armiranobetonska dela** | 108.68d | 2004-09-30 A | 2005-02-16 A |  | 100% | 2004-09-30 | 2005-01-12 | 78.77d |  |  | 4564h | 4564h | 35,917,466.38 | 29,120,164.62 | 35,917,466.38 |
| 9 | 2.2.1 | Podložni betoni | 6.84d | 2004-09-30 A | 2004-10-07 A | 6SS+2d | 100% | 2004-09-30 | 2004-10-06 | 4.31d | start no earlier than 2004-09-30 | Delavec [463.2%] | 251h | 251h | 768,880 | 514,970.4 | 768,880 |
| 10 | 2.2.2 | Pasovni temelji | 7.84d | 2004-10-12 A | 2004-10-23 A | 30SS+3d | 100% | 2004-10-07 | 2004-10-21 | 11.82d | start no earlier than 2004-10-12 | Delavec [700%] | 324h | 324h | 3,391,326.12 | 3,409,398.13 | 3,391,326.12 |
| 11 | 2.2.3 | Nastavki temeljev | 7.84d | 2004-10-26 A | 2004-11-08 A | 31FS+2d | 100% | 2004-10-27 | 2004-11-09 | 9.86d | start no earlier than 2004-10-26 | Delavec [1389.5%] | 536h | 536h | 3,824,345.52 | 5,462,452.87 | 3,824,345.52 |
| 12 | 2.2.4 | zastoj - sprememba projektov | 12.68d | 2004-11-09 A | 2004-11-23 A | 11 | 100% |  |  |  |  | Delavec [526.3%] | 398h | 398h | 2,011,579.15 |  | 2,011,579.15 |
| 13 | 2.2.5 | nastavki temeljev - 65 cm | 7.68d | 2004-11-24 A | 2004-12-06 A | 32SS+2d | 100% |  |  |  |  | Delavec [1263.2%] | 586h | 586h | 3,778,235.55 |  | 3,778,235.55 |
| 14 | 2.2.6 | AB kinete | 2d | 2004-12-08 A | 2004-12-13 A | 33SS+1d | 100% | 2004-11-02 | 2004-11-10 | 7.27d | finish no earlier than 2004-12-14 | Delavec [210.5%] | 40h | 40h | 230,496 | 1,412,674.28 | 230,496 |
| 15 | 2.2.7 | Temeljna plošča | 3d | 2004-12-08 A | 2004-12-13 A | 34 | 100% | 2004-11-15 | 2004-11-19 | 4.85d | start no earlier than 2004-12-08 | Delavec [1473.7%] | 325h | 325h | 4,779,939.5 | 4,736,086.3 | 4,779,939.5 |
| 16 | 2.2.8 | Stene pritličje | 8.84d | 2004-12-14 A | 2005-01-17 A | 35SS+3d | 100% | 2004-11-26 | 2004-12-06 | 8.24d |  | Delavec [1473.7%] | 688h | 688h | 3,447,951.03 | 2,893,535.81 | 3,447,951.03 |
| 17 | 2.2.9 | Dvigalni jašek | 2.84d | 2004-12-18 A | 2005-02-15 A | 36SS+4d | 100% | 2004-12-08 | 2004-12-18 | 8d |  | Delavec [684.2%] | 105h | 105h | 841,661.14 |  | 841,661.14 |
| 18 | 2.2.10 | Plošča I. Nadstropje | 3.84d | 2004-12-23 A | 2005-01-22 A | 37 | 100% | 2004-12-10 | 2004-12-15 | 4.01d |  | Delavec [1284.2%] | 324h | 324h | 4,401,992.24 | 4,181,796.81 | 4,401,992.24 |
| 19 | 2.2.11 | Stene,stebri I. Nadstropje | 10d | 2005-01-17 A | 2005-02-16 A | 38SS+1d | 100% | 2004-12-16 | 2004-12-21 | 4.02d |  | Delavec [1368.4%] | 649h | 649h | 4,644,456.32 | 3,208,133.28 | 4,644,456.32 |
| 20 | 2.2.12 | Plošča II. Nadstropje | 7d | 2005-01-25 A | 2005-02-16 A | 39 | 100% | 2005-01-06 | 2005-01-12 | 4.63d |  | Delavec [894.7%] | 302h | 302h | 3,514,184.17 | 3,213,631.19 | 3,514,184.17 |
| 21 | 2.2.13 | Stopnišče | 2d | 2005-01-12 A | 2005-01-16 A | 40FS+6d | 100% | 2005-01-03 | 2005-01-04 | 0.45d |  | Delavec [210.5%] | 36h | 36h | 282,419.64 | 87,485.55 | 282,419.64 |
| 22 | 2.3 | **Zidarska dela** | 126.21d | 2004-12-08 A | 2005-05-19 A |  | 100% | 2004-11-13 | 2005-03-26 | 104.24d |  |  | 2923h | 2923h | 13,133,140.36 | 13,936,464.49 | 13,133,140.36 |
| 23 | 2.3.1 | Hidroizolacija tlaka | 85.58d | 2004-12-14 A | 2005-04-04 A | 18FS+7d | 100% | 2004-12-23 | 2005-01-03 | 2.87d |  |  |  |  | 946,306.06 | 1,241,149.43 | 946,306.06 |
| 24 | 2.3.2 | Zidanje sten | 25.53d | 2005-01-20 A | 2005-03-15 A | 23 | 100% | 2005-01-03 | 2005-01-28 | 20.65d |  | Delavec [675%] | 1030h | 1030h | 3,156,342.32 | 3,262,924.91 | 3,156,342.32 |
| 25 | 2.3.3 | Estrihi | 6d | 2005-03-30 A | 2005-04-07 A | 26FS+2d, 69SS+4d | 100% | 2005-03-15 | 2005-03-26 | 10.11d |  | Delavec [315.8%] | 135h | 135h | 4,999,011.32 | 5,611,060.34 | 4,999,011.32 |
| 26 | 2.3.4 | Ometi sten | 10.68d | 2005-04-02 A | 2005-04-14 A | 24FS+10d | 100% | 2005-02-10 | 2005-02-24 | 12.17d |  |  |  |  | 1,144,115.38 | 2,993,637.51 | 1,144,115.38 |
| 27 | 2.3.5 | Hišna kanalizacija | 3.84d | 2004-12-08 A | 2004-12-11 A | 15FF-2d | 100% | 2004-11-13 | 2004-11-17 | 3.47d |  | Delavec [168.4%] | 26h | 26h | 97,131.25 | 90,250 | 97,131.25 |
| 28 | 2.3.6 | Vzidave, zidarske obdelave | 40.89d | 2005-01-14 A | 2005-05-19 A | 24 | 100% | 2005-01-28 | 2005-03-01 | 25.65d | finish no earlier than 2005-05-19 | Delavec [1263.2%] | 1732h | 1732h | 2,790,234.03 | 737,442.3 | 2,790,234.03 |

| ID | WBS | Task | Type | Duration | Start | Finish | Predecessors | Complete | Baseline start | Baseline finish | Baseline duration | Resources | Work | Actual work | Cost | Baseline cost | Actual cost |
| --- | --- | --- | --- | --- | --- | --- | --- | --- | --- | --- | --- | --- | --- | --- | --- | --- | --- |
| 29 | 2.4 | **Tesarska dela** |  | 175.74d | 2004-10-08 A | 2005-05-19 A |  | 100% | 2004-10-04 | 2005-04-19 | 156.38d |  | 9260.5h | 9260.5h | 19,560,572.95 | 11,294,985.22 | 19,560,572.95 |
| 30 | 2.4.1 | Opaž-Pasovni temelji |  | 12.84d | 2004-10-08 A | 2004-10-25 A | 9FS-2d | 100% | 2004-10-04 | 2004-10-16 | 10.95d | Delavec [715.8%] | 503h | 503h | 1,013,490.92 | 766,001.76 | 1,013,490.92 |
| 31 | 2.4.2 | Opaž-Nastavki temeljev |  | 13.68d | 2004-10-21 A | 2004-11-09 A | 10SS+3d | 100% | 2004-10-11 | 2004-10-25 | 11.56d | Delavec [1578.9%] | 1035h | 1035h | 2,155,584.86 | 2,237,130.24 | 2,155,584.86 |
| 32 | 2.4.3 | opaž - nastavki temeljev 65 cm |  | 13.68d | 2004-11-23 A | 2004-12-07 A | 12 | 100% |  |  |  | Delavec [2210.5%] | 1132h | 1132h | 2,128,646.07 |  | 2,128,646.07 |
| 33 | 2.4.4 | Opaž-AB kinete |  | 6d | 2004-12-02 A | 2004-12-10 A | 11SS+3d | 100% | 2004-10-30 | 2004-11-09 | 7d | Delavec [784.2%] | 268.5h | 268.5h | 474,480.92 |  | 474,480.92 |
| 34 | 2.4.5 | Opaž-Temeljna plošča |  | 6.84d | 2004-12-06 A | 2004-12-14 A | 14 | 100% | 2004-11-10 | 2004-11-15 | 3d | Delavec [1575%] | 276h | 276h | 408,044.7 |  | 408,044.7 |
| 35 | 2.4.6 | Opaž-Stene pritličje |  | 19.53d | 2004-12-11 A | 2005-01-18 A | 15FS+2d | 100% | 2004-11-23 | 2004-12-03 | 9.51d | Delavec [1263.2%] | 982h | 982h | 2,428,336.45 | 1,208,599.66 | 2,428,336.45 |
| 36 | 2.4.7 | Opaž-Dvigalni jašek |  | 8.53d | 2004-12-18 A | 2005-02-15 A | 35 | 100% | 2004-12-03 | 2004-12-16 | 10d | Delavec [500%] | 232h | 232h | 411,472.11 |  | 411,472.11 |
| 37 | 2.4.8 | Opaž-Plošča I. Nadstropje |  | 22.53d | 2004-12-16 A | 2005-01-29 A | 16SS+5d | 100% | 2004-12-02 | 2004-12-10 | 6.95d | Delavec [1989.5%] | 1272h | 1272h | 3,486,555.56 | 2,217,487.59 | 3,486,555.56 |
| 38 | 2.4.9 | Opaž-Stene,stene stebri I. Nadstropje |  | 26.37d | 2005-01-13 A | 2005-02-17 A | 18 | 100% | 2004-12-15 | 2004-12-20 | 4.04d | Delavec [1473.7%] | 1307h | 1307h | 2,732,508.21 | 1,380,650.38 | 2,732,508.21 |
| 39 | 2.4.10 | Opaž-Plošča II. Nadstropje |  | 25.53d | 2005-01-24 A | 2005-02-28 A | 19 | 100% | 2004-12-21 | 2005-01-06 | 7.17d | Delavec [1663.2%] | 1337h | 1337h | 2,761,521.84 | 2,142,070 | 2,761,521.84 |
| 40 | 2.4.11 | Opaž-Stopnišče |  | 7.84d | 2005-01-03 A | 2005-01-15 A | 18 | 100% | 2004-12-15 | 2004-12-20 | 3.52d | Delavec [189.5%] | 97h | 97h | 156,606.95 | 67,408.96 | 156,606.95 |
| 41 | 2.4.12 | Fasadni odri |  | 23.53d | 2005-01-17 A | 2005-05-19 A | 71SS-5d | 100% | 2005-03-16 | 2005-04-19 | 28.06d | Delavec [631.6%] | 819h | 819h | 1,403,324.36 | 1,275,636.63 | 1,403,324.36 |
| 42 | 2.5 | **Pomožni objekt** |  | 67.05d | 2005-03-18 A | 2005-06-09 A |  | 100% | 2005-03-26 | 2005-04-19 | 19.58d |  | 445h | 445h | 2,127,475.01 | 1,686,296.35 | 2,127,475.01 |
| 43 | 2.5.1 | Groba gradnja |  | 14.68d | 2005-03-18 A | 2005-04-11 A | 22 | 100% | 2005-03-26 | 2005-04-11 | 12.58d | Delavec [675%] | 445h | 445h | 1,251,090.4 | 1,178,625.6 | 1,251,090.4 |
| 44 | 2.5.2 | Finalizacija-agrgat, smeti |  | 46.68d | 2005-04-12 A | 2005-06-09 A | 43 | 100% | 2005-04-11 | 2005-04-19 | 7d |  |  |  | 876,384.61 | 507,670.75 | 876,384.61 |
| 45 | 2.6 | **Kanalizacija** |  | 122.37d | 2004-11-30 A | 2005-05-06 A |  | 100% | 2004-11-11 | 2005-04-07 | 115.08d |  | 886h | 886h | 6,418,646.74 | 8,312,835.81 | 6,418,646.74 |
| 46 | 2.6.1 | Priključni kanal |  | 5d | 2005-03-21 A | 2005-03-25 A | 22FS-7d | 100% | 2005-03-18 | 2005-03-23 | 4.32d | Delavec [105.3%] | 40h | 40h | 598,349.65 | 318,761.09 | 598,349.65 |
| 47 | 2.6.2 | Notranja kanalizacija |  | 5d | 2004-11-30 A | 2004-12-09 A | 15FF-2d | 100% | 2004-11-11 | 2004-11-17 | 5.13d | Delavec [726.3%] | 171h | 171h | 787,753.34 | 795,805.49 | 787,753.34 |
| 48 | 2.6.3 | Zunanja kanalizacija-fekalna |  | 5.84d | 2005-04-21 A | 2005-05-06 A | 46 | 100% | 2005-03-23 | 2005-03-29 | 4.9d | Delavec [421.1%] | 150h | 150h | 1,355,292.25 | 2,036,376.29 | 1,355,292.25 |
| 49 | 2.6.4 | Zunanja kanalizacija-meteorna |  | 9.68d | 2005-04-15 A | 2005-05-06 A | 48 | 100% | 2005-03-29 | 2005-04-07 | 6.97d | Delavec [947.4%] | 525h | 525h | 3,677,251.5 | 5,161,892.92 | 3,677,251.5 |
| 50 | 2.7 | **Zunanja ureditev** |  | 46.68d | 2005-04-12 A | 2005-06-09 A |  | 100% | 2005-04-12 | 2005-05-18 | 27.59d |  | 1704h | 1704h | 7,478,140.52 | 13,325,783.41 | 7,478,140.52 |
| 51 | 2.7.1 | Zemeljska dela, izkop, planum |  | 11.63d | 2005-04-20 A | 2005-05-06 A | 49FS+4d | 100% | 2005-04-12 | 2005-04-18 | 4.74d |  |  |  | 2,282,120 | 2,208,199 | 2,282,120 |
| 52 | 2.7.2 | Robni elementi, kanalete, jaški |  | 23.53d | 2005-04-12 A | 2005-05-27 A | 51 | 100% | 2005-04-18 | 2005-05-03 | 10.35d | Delavec [1157.9%] | 1426h | 1426h | 2,608,588.31 | 5,422,448.33 | 2,608,588.31 |
| 53 | 2.7.3 | Asfalt |  | 2d | 2005-05-23 A | 2005-05-24 A | 55 | 100% | 2005-05-11 | 2005-05-17 | 4d |  |  |  | 2,130,410.21 | 2,156,310 | 2,130,410.21 |
| 54 | 2.7.4 | Oprema cest | milestone | 0d | 2005-05-24 A | 2005-05-25 A | 53 | 100% | 2005-05-17 | 2005-05-18 | 1.63d | Delavec [50%] |  |  | 48,182 | 216,975.73 | 48,182 |
| 55 | 2.7.5 | Hortikulturna ureditev |  | 12.68d | 2005-05-25 A | 2005-06-09 A | 52 | 100% | 2005-05-03 | 2005-05-11 | 6.86d | Delavec [526.3%] | 278h | 278h | 408,840 | 3,321,850.35 | 408,840 |

| ID | WBS | Task | Duration | Start | Finish | Predecessors | Complete | Baseline start | Baseline finish | Baseline duration | Work | Actual work | Cost | Baseline cost | Actual cost |
| --- | --- | --- | --- | --- | --- | --- | --- | --- | --- | --- | --- | --- | --- | --- | --- |
| 57 | 3 | **OBRTNIŠKA DELA** | 101.42d | 2005-03-07 A | 2005-07-11 A |  | 100% | 2005-01-20 | 2005-07-04 | 132.99d | 556h | 556h | 113,793,377.44 | 137,954,589.6 | 113,793,377.44 |
| 58 | 3.1 | Lesene konstrikcije | 35.05d | 2005-03-11 A | 2005-04-21 A | 20FS+7d | 100% | 2005-01-20 | 2005-01-28 | 7d |  |  | 7,985,443.35 | 10,464,346.84 | 7,985,443.35 |
| 59 | 3.2 | Krovska dela | 26.37d | 2005-03-23 A | 2005-04-22 A | 58 | 100% | 2005-01-28 | 2005-02-10 | 10d |  |  | 6,950,328 | 6,231,396.47 | 6,950,328 |
| 60 | 3.3 | Kleparska dela | 12.68d | 2005-04-12 A | 2005-04-26 A | 61 | 100% | 2005-02-15 | 2005-02-28 | 10d |  |  | 1,650,761 | 1,042,657.3 | 1,650,761 |
| 61 | 3.4 | Strešna okna, lopute | 3.84d | 2005-03-30 A | 2005-04-02 A | 59 | 100% | 2005-02-10 | 2005-02-15 | 4d |  |  | 320,974 | 244,150 | 320,974 |
| 62 | 3.5 | **Ključavničarska dela** | 26.21d | 2005-05-05 A | 2005-06-04 A |  | 100% | 2005-03-26 | 2005-05-07 | 32d |  |  | 4,550,281.04 | 4,117,722.76 | 4,550,281.04 |
| 63 | 3.5.1 | Ograje, ročaji | 14.53d | 2005-05-19 A | 2005-06-04 A | 25FS+5d | 100% | 2005-04-01 | 2005-04-11 | 7d |  |  | 2,021,267 | 1,409,243.3 | 2,021,267 |
| 64 | 3.5.2 | Drsna kovinska vrata | 19.53d | 2005-05-05 A | 2005-05-27 A | 25 | 100% | 2005-03-26 | 2005-04-01 | 5d |  |  | 1,458,000 | 1,147,600 | 1,458,000 |
| 65 | 3.5.3 | Dvižna vrata | 5.84d | 2005-05-28 A | 2005-06-03 A | 64 | 100% | 2005-04-01 | 2005-04-07 | 5d |  |  | 314,814.04 | 754,110 | 314,814.04 |
| 66 | 3.5.4 | WC kabine | 5.84d | 2005-05-24 A | 2005-05-30 A | 83FS+2d | 100% | 2005-05-02 | 2005-05-07 | 5d |  |  | 756,200 | 806,769.46 | 756,200 |
| 67 | 3.6 | **Okna, Vrata** | 61.21d | 2005-03-08 A | 2005-05-23 A |  | 100% | 2005-03-01 | 2005-05-11 | 57.11d |  |  | 18,864,270 | 15,304,376.5 | 18,864,270 |
| 68 | 3.6.1 | Obodne zasteklitve | 28.21d | 2005-03-08 A | 2005-04-09 A | 26FS+3d | 100% | 2005-03-01 | 2005-03-10 | 8d |  |  | 1,548,100 | 1,470,695 | 1,548,100 |
| 69 | 3.6.2 | Okna | 28.21d | 2005-03-10 A | 2005-04-12 A | 68 | 100% | 2005-03-10 | 2005-03-22 | 10d |  |  | 5,801,080 | 5,493,926 | 5,801,080 |
| 70 | 3.6.3 | Obrobe, alu police, senčila | 41.68d | 2005-03-31 A | 2005-05-23 A | 71 | 100% | 2005-03-31 | 2005-04-07 | 6d |  |  | 2,736,400 | 1,136,086 | 2,736,400 |
| 71 | 3.6.4 | Fasadni elementi | 8.68d | 2005-04-09 A | 2005-04-19 A | 69 | 100% | 2005-03-22 | 2005-03-31 | 8d |  |  | 5,979,400 | 4,544,344 | 5,979,400 |
| 72 | 3.6.5 | Notranje steklene stene | 5.84d | 2005-05-04 A | 2005-05-10 A | 85 | 100% | 2005-04-26 | 2005-05-05 | 5d |  |  | 1,771,200 | 1,682,640 | 1,771,200 |
| 73 | 3.6.6 | Alu vrata | 1d | 2005-04-14 A | 2005-04-14 A | 72 | 100% | 2005-05-05 | 2005-05-11 | 5d |  |  | 1,028,090 | 976,685.5 | 1,028,090 |
| 74 | 3.7 | Mizarska dela | 6.68d | 2005-05-21 A | 2005-05-28 A | 93 | 100% | 2005-05-28 | 2005-06-09 | 10d |  |  | 5,707,047.68 | 5,385,625.05 | 5,707,047.68 |
| 75 | 3.8 | **Fasaderska dela** | 52.53d | 2005-03-23 A | 2005-05-27 A |  | 100% | 2005-03-24 | 2005-04-20 | 22d |  |  | 8,372,370.25 | 18,316,329.62 | 8,372,370.25 |
| 76 | 3.8.1 | Tanakoslojna fasada | 35.84d | 2005-03-23 A | 2005-05-07 A | 69, 41FF-7d | 100% | 2005-03-24 | 2005-04-11 | 14d |  |  | 3,319,286.65 | 3,716,747.47 | 3,319,286.65 |
| 77 | 3.8.2 | Leseni del fasade | 31d | 2005-04-12 A | 2005-05-21 A | 41FF-4d | 100% | 2005-03-30 | 2005-04-14 | 12d |  |  | 5,053,083.6 | 8,292,704 | 5,053,083.6 |
| 78 | 3.8.3 | Zaključki | 5d | 2005-05-23 A | 2005-05-27 A | 77 | 100% | 2005-04-14 | 2005-04-20 | 5d |  |  |  | 6,306,878.15 |  |
| 79 | 3.9 | **Kamnoseška dela** | 18.32d | 2005-04-22 A | 2005-05-17 A |  | 100% | 2005-04-26 | 2005-05-09 | 8d |  |  | 1,271,891.58 | 1,368,557.65 | 1,271,891.58 |
| 80 | 3.9.1 | Tlaki | 6.84d | 2005-05-09 A | 2005-05-16 A | 83 | 100% | 2005-04-26 | 2005-05-05 | 5d |  |  | 510,403.41 | 549,195 | 510,403.41 |
| 81 | 3.9.2 | Portali | 7.84d | 2005-05-09 A | 2005-05-17 A | 80 | 100% | 2005-05-05 | 2005-05-09 | 3d |  |  | 166,539.31 | 179,196.6 | 166,539.31 |
| 82 | 3.9.3 | Okenske police | 1.84d | 2005-04-22 A | 2005-04-23 A | 80 | 100% | 2005-05-05 | 2005-05-09 | 3d |  |  | 594,948.86 | 640,166.05 | 594,948.86 |

| ID | WBS | Task | Duration | Start | Finish | Predecessors | Complete | Baseline start | Baseline finish | Baseline duration | Constraint | Resources | Work | Actual work | Cost | Baseline cost | Actual cost |
| --- | --- | --- | --- | --- | --- | --- | --- | --- | --- | --- | --- | --- | --- | --- | --- | --- | --- |
| 83 | 3.10 | **Keramičarska dela** | 31.16d | 2005-04-11 A | 2005-05-20 A |  | 100% | 2005-04-01 | 2005-04-26 | 20d |  |  |  |  | 3,269,598.19 | 4,656,422.12 | 3,269,598.19 |
| 84 | 3.10.1 | Stenska obloga | 25.16d | 2005-04-14 A | 2005-05-17 A | 25FS+5d | 100% | 2005-04-01 | 2005-04-14 | 10d |  |  |  |  | 1,922,907.59 | 2,738,522.87 | 1,922,907.59 |
| 85 | 3.10.2 | Tlaki2 | 31.16d | 2005-04-11 A | 2005-05-20 A | 84 | 100% | 2005-04-14 | 2005-04-26 | 10d |  |  |  |  | 1,346,690.6 | 1,917,899.25 | 1,346,690.6 |
| 86 | 3.11 | **Mavčarska dela** | 24.32d | 2005-04-12 A | 2005-05-13 A |  | 100% | 2005-04-19 | 2005-06-14 | 44d |  |  |  |  | 4,830,977.24 | 4,673,397.08 | 4,830,977.24 |
| 87 | 3.11.1 | Predelne stene | 24.32d | 2005-04-12 A | 2005-05-13 A | 92FF | 100% | 2005-04-19 | 2005-05-04 | 10d |  |  |  |  | 1,528,079.86 | 1,717,193.4 | 1,528,079.86 |
| 88 | 3.11.2 | Spuščeni stropovi | 21.32d | 2005-04-15 A | 2005-05-13 A | 93 | 100% | 2005-05-28 | 2005-06-14 | 14d |  |  |  |  | 3,302,897.38 | 2,956,203.68 | 3,302,897.38 |
| 89 | 3.12 | Montaža dvigala | 30d | 2005-04-13 A | 2005-05-21 A | 25FS+10d | 100% | 2005-04-07 | 2005-04-25 | 14d |  |  |  |  | 3,123,200 | 3,724,916.75 | 3,123,200 |
| 90 | 3.13 | Razna dela | 3.84d | 2005-05-18 A | 2005-05-21 A | 93 | 100% | 2005-05-28 | 2005-06-01 | 3d |  |  |  |  | 551,415.18 | 341,563 | 551,415.18 |
| 91 | 3.14 | **Slikopleskarska dela** | 40.84d | 2005-04-19 A | 2005-06-09 A |  | 100% | 2005-04-01 | 2005-06-24 | 67d |  |  |  |  | 1,701,194.65 | 1,904,900.63 | 1,701,194.65 |
| 92 | 3.14.1 | Kitanje sten in stropov | 21.32d | 2005-04-19 A | 2005-05-17 A | 25FS+5d, 26FS+20d | 100% | 2005-04-01 | 2005-05-04 | 24d |  |  |  |  | 465,001.55 | 520,682.17 | 465,001.55 |
| 93 | 3.14.2 | Slikanje ometanih sten,stropov | 19.53d | 2005-05-05 A | 2005-05-27 A | 92 | 100% | 2005-05-04 | 2005-05-28 | 20d |  |  |  |  | 812,228.93 | 909,487.6 | 812,228.93 |
| 94 | 3.14.3 | Slikanje knauf sten | 11.68d | 2005-05-14 A | 2005-05-27 A | 93FF | 100% | 2005-05-13 | 2005-05-28 | 12d |  |  |  |  | 423,964.17 | 474,730.86 | 423,964.17 |
| 95 | 3.14.4 | Slikopleskarska razna dela, popravila | 11.68d | 2005-05-27 A | 2005-06-09 A | 88 | 100% | 2005-06-14 | 2005-06-24 | 9d |  |  |  |  |  |  |  |
| 96 | 3.15 | Tlakarska dela | 13.68d | 2005-05-19 A | 2005-06-03 A | 88SS+8d | 100% | 2005-06-07 | 2005-06-24 | 15d |  |  |  |  | 5,952,475.2 | 5,823,750.54 | 5,952,475.2 |
| 97 | 3.16 | **STROJNE INSTALACIJE** | 80.74d | 2005-03-08 A | 2005-06-15 A |  | 100% | 2005-02-11 | 2005-06-15 | 100d |  |  |  |  | 20,404,258.46 | 31,853,682.22 | 20,404,258.46 |
| 98 | 3.16.1 | Groba montaža | 70.05d | 2005-03-08 A | 2005-06-02 A | 87FF+5d | 100% | 2005-02-11 | 2005-05-10 | 70d |  |  |  |  | 16,413,312.4 | 25,623,300.07 | 16,413,312.4 |
| 99 | 3.16.2 | Fina montaža | 20.53d | 2005-05-23 A | 2005-06-15 A | 98FS+10d | 100% | 2005-05-23 | 2005-06-15 | 20d |  |  |  |  | 3,990,946.06 | 6,230,382.15 | 3,990,946.06 |
| 100 | 3.17 | **ELEKTROINSTALACIJE** | 90.58d | 2005-03-07 A | 2005-06-27 A |  | 100% | 2005-02-11 | 2005-06-21 | 105d |  |  |  |  | 17,519,611.62 | 22,501,395.07 | 17,519,611.62 |
| 101 | 3.17.1 | Groba montaža2 | 81.74d | 2005-03-07 A | 2005-06-15 A | 98FF+10d | 100% | 2005-02-11 | 2005-05-23 | 80d |  |  |  |  | 17,128,510.16 | 21,998,495.47 | 17,128,510.16 |
| 102 | 3.17.2 | Fina montaža 2 | 14.68d | 2005-06-09 A | 2005-06-27 A | 101FS+5d | 100% | 2005-05-28 | 2005-06-21 | 20d |  |  |  |  | 391,101.46 | 502,899.6 | 391,101.46 |
| 104 | 3.18 | Finalizacija del | 8.84d | 2005-06-30 A | 2005-07-11 A | 96 | 100% | 2005-06-24 | 2005-07-04 | 7d |  |  |  |  |  | 2,590,367.4 |  |
| 105 | 3.19 | grobo čiščenje | 31d | 2005-03-29 A | 2005-06-17 A |  | 100% |  |  |  |  | Delavec [421.1%] | 556h | 556h | 767,280 |  | 767,280 |
| 106 | 4 | Finalno čiščenje | 4.84d | 2005-07-12 A | 2005-07-16 A | 104 | 100% | 2005-07-04 | 2005-07-08 | 3.95d |  |  |  |  | 437,817.41 | 661,943.28 | 437,817.41 |
| 107 | 5 | Tehnični pregled | 1d | 2005-07-22 A | 2005-07-22 A | 106 | 100% | 2005-07-08 | 2005-07-09 | 1d |  |  |  |  | 1,795,086.35 |  | 1,795,086.35 |
| 108 | 6 | Oprava napak pred predajo objekta | 12.53d | 2005-07-23 A | 2005-08-06 A | 107 | 100% | 2005-07-09 | 2005-07-20 | 8d |  |  |  |  |  |  |  |
| 109 | 7 | Primopredaja objekta | 1d | 2005-08-08 A | 2005-08-08 A | 108 | 100% | 2005-07-20 | 2005-07-22 | 2d |  |  |  |  |  |  |  |
| 110 | 8 | stroški gradbišča, njemnia za osnovna sredstva, transport | 227.37d | 2004-09-17 A | 2005-07-01 A |  | 100% |  |  |  | start no earlier than 2004-09-17 |  |  |  | 10,209,701.81 |  | 10,209,701.81 |
| 111 | 9 | najem prevoznega sredstva, prevoz delavcev | 170.89d | 2004-10-26 A | 2005-05-31 A |  | 100% |  |  |  |  |  |  |  | 1,267,500 |  | 1,267,500 |
| 112 | 10 | režija | 253.58d | 2004-09-17 A | 2005-08-02 A |  | 100% |  |  |  |  |  |  |  | 2,085,639.52 |  | 2,085,639.52 |
| 113 | 11 | stroški zaposlenih, stroški podjetja | 227.37d | 2004-09-17 A | 2005-07-01 A |  | 100% |  |  |  |  |  |  |  | 10,154,501.5 |  | 10,154,501.5 |
