# VDC Cernknica G+O+I

Schedule from MS Project, 2004-09-21 to 2005-07-22, 9.5 hours a day, costs in SIT.
ENERGOPLAN D.D.

## Calendars

- Standard: Mon-Fri 07:00-10:00, 10:30-17:00; Sat 07:00-10:00, 10:30-15:00; Sun off. Exceptions (off unless hours are given): 2004-10-02 08:00-12:00, 13:00-17:00, 2004-10-09 08:00-12:00, 13:00-17:00, 2004-10-16 08:00-12:00, 13:00-17:00, 2004-10-23 08:00-12:00, 13:00-17:00, 2004-11-01, 2004-11-06 08:00-12:00, 13:00-17:00, 2004-11-13 08:00-12:00, 13:00-17:00, 2004-11-20 08:00-12:00, 13:00-17:00, 2004-11-27 08:00-12:00, 13:00-17:00, 2004-12-04 08:00-12:00, 13:00-17:00, 2004-12-11 08:00-12:00, 13:00-17:00, 2004-12-18 08:00-12:00, 13:00-17:00, 2004-12-24, 2004-12-27 to 2004-12-31, 2005-01-08 08:00-12:00, 13:00-17:00, 2005-01-15 08:00-12:00, 13:00-17:00, 2005-01-22 08:00-12:00, 13:00-17:00, 2005-01-29 08:00-12:00, 13:00-17:00, 2005-02-05 08:00-12:00, 13:00-17:00, 2005-02-08, 2005-02-12 08:00-12:00, 13:00-17:00, 2005-02-19 08:00-12:00, 13:00-17:00, 2005-02-26 08:00-12:00, 13:00-17:00, 2005-03-05 08:00-12:00, 13:00-17:00, 2005-03-12 08:00-12:00, 13:00-17:00, 2005-03-19 08:00-12:00, 13:00-17:00, 2005-03-26 08:00-12:00, 13:00-17:00, 2005-04-02 08:00-12:00, 13:00-17:00, 2005-04-09 08:00-12:00, 13:00-17:00, 2005-04-16 08:00-12:00, 13:00-17:00, 2005-04-23 08:00-12:00, 13:00-17:00, 2005-04-27 to 2005-04-29, 2005-05-07 08:00-12:00, 13:00-17:00, 2005-05-14 08:00-12:00, 13:00-17:00, 2005-05-21 08:00-12:00, 13:00-17:00, 2005-05-28 08:00-12:00, 13:00-17:00, 2005-06-04 08:00-12:00, 13:00-17:00, 2005-06-11 08:00-12:00, 13:00-17:00, 2005-06-18 08:00-12:00, 13:00-17:00, 2005-06-25, 2005-07-02 08:00-12:00, 13:00-17:00, 2005-07-09 08:00-12:00, 13:00-17:00, 2005-07-16 08:00-12:00, 13:00-17:00.

## Resources

| Resource | Rate |
| --- | --- |
| Delavec | 1757.5 |
| železokrivec | 1757.5 |
| tesar | 1757.5 |

## Schedule

| ID | WBS | Task | Duration | Start | Finish | Predecessors | Baseline start | Baseline finish | Baseline duration | Total slack | Free slack | Resources | Work | Cost | Baseline cost |
| --- | --- | --- | --- | --- | --- | --- | --- | --- | --- | --- | --- | --- | --- | --- | --- |
| 1 | 1 | **Pripravljalna dela** | 7d | 2004-09-21 | 2004-09-29 |  | 2004-09-21 | 2005-07-22 | 242.14d | 0d |  |  | 33.25h | 71,249.99 | 218,982,925.22 |
| 2 | 1.1 | Zakoličba, postavitev gradbišča | 7d | 2004-09-21 | 2004-09-29 |  | 2004-09-21 | 2004-09-29 | 7d | 0d |  | Delavec [50%] | 33.25h | 71,249.99 | 71,249.99 |
| 3 | 2 | **GRADBENA DELA** | 185.15d | 2004-09-25 | 2005-05-18 |  | 2004-09-25 | 2005-05-18 | 185.15d | 0d |  |  | 12642.6h | 80,295,142.34 | 80,295,142.34 |
| 4 | 2.1 | **Zemeljska dela** | 35.84d | 2004-09-25 | 2004-11-09 |  | 2004-09-25 | 2004-11-09 | 35.84d | 0d |  |  | 441.8h | 2,618,612.44 | 2,618,612.44 |
| 5 | 2.1.1 | Odriv humusa | 2.43d | 2004-09-25 | 2004-09-28 | 2SS+4d | 2004-09-25 | 2004-09-28 | 2.43d | 0d |  | Delavec [50%] | 11.55h | 322,700.01 | 322,700.01 |
| 6 | 2.1.2 | Široki izkop | 7.24d | 2004-09-28 | 2004-10-07 | 5 | 2004-09-28 | 2004-10-07 | 7.24d | 0d |  | Delavec [400%] | 275.18h | 1,271,086.76 | 1,271,086.76 |
| 7 | 2.1.3 | Zasip temeljev | 6.53d | 2004-10-30 | 2004-11-09 | 11SS+3d | 2004-10-30 | 2004-11-09 | 6.53d | 202.3d |  | Delavec [250%] | 155.07h | 1,024,825.68 | 1,024,825.68 |
| 8 | 2.2 | **Armiranobetonska dela** | 78.77d | 2004-09-30 | 2005-01-12 |  | 2004-09-30 | 2005-01-12 | 78.77d | 0d |  |  | 1562.47h | 29,120,164.62 | 29,120,164.62 |
| 9 | 2.2.1 | Podložni betoni | 4.31d | 2004-09-30 | 2004-10-06 | 6SS+2d | 2004-09-30 | 2004-10-06 | 4.31d | 0d |  | Delavec [200%] | 81.97h | 514,970.4 | 514,970.4 |
| 10 | 2.2.2 | Pasovni temelji | 11.82d | 2004-10-07 | 2004-10-21 | 28SS+3d | 2004-10-07 | 2004-10-21 | 11.82d | 0d |  | Delavec | 112.31h | 3,409,398.13 | 3,409,398.13 |
| 11 | 2.2.3 | Nastavki temeljev | 9.86d | 2004-10-27 | 2004-11-09 | 29FS+2d | 2004-10-27 | 2004-11-09 | 9.86d | 0d |  | Delavec [200%] | 187.3h | 5,462,452.87 | 5,462,452.87 |
| 12 | 2.2.4 | AB kinete | 7.27d | 2004-11-02 | 2004-11-10 | 30SS+1d | 2004-11-02 | 2004-11-10 | 7.27d | 0d |  | Delavec [250%] | 172.55h | 1,412,674.28 | 1,412,674.28 |
| 13 | 2.2.5 | Temeljna plošča | 4.85d | 2004-11-15 | 2004-11-19 | 31 | 2004-11-15 | 2004-11-19 | 4.85d | 0d |  | Delavec [500%] | 230.24h | 4,736,086.3 | 4,736,086.3 |
| 14 | 2.2.6 | Stene pritličje | 8.24d | 2004-11-26 | 2004-12-06 | 32SS+3d | 2004-11-26 | 2004-12-06 | 8.24d | 0d |  | Delavec [200%] | 156.6h | 2,893,535.81 | 2,893,535.81 |
| 15 | 2.2.7 | Dvigalni jašek | 8d | 2004-12-08 | 2004-12-18 | 33SS+4d | 2004-12-08 | 2004-12-18 | 8d | 169.21d |  |  |  |  |  |
| 16 | 2.2.8 | Plošča I. Nadstropje | 4.01d | 2004-12-10 | 2004-12-15 | 34 | 2004-12-10 | 2004-12-15 | 4.01d | 0d |  | Delavec [650%] | 247.41h | 4,181,796.81 | 4,181,796.81 |
| 17 | 2.2.9 | Stene,stebri I. Nadstropje | 4.02d | 2004-12-16 | 2004-12-21 | 35SS+1d | 2004-12-16 | 2004-12-21 | 4.02d | 116.94d | 0d | Delavec [450%] | 171.88h | 3,208,133.28 | 3,208,133.28 |
| 18 | 2.2.10 | Plošča II. Nadstropje | 4.63d | 2005-01-06 | 2005-01-12 | 36 | 2005-01-06 | 2005-01-12 | 4.63d | 116.94d | 0d | Delavec [450%] | 197.93h | 3,213,631.19 | 3,213,631.19 |
| 19 | 2.2.11 | Stopnišče | 0.45d | 2005-01-03 | 2005-01-04 | 37FS+6d | 2005-01-03 | 2005-01-04 | 0.45d | 161.79d |  | Delavec | 4.28h | 87,485.55 | 87,485.55 |
| 20 | 2.3 | **Zidarska dela** | 104.24d | 2004-11-13 | 2005-03-26 |  | 2004-11-13 | 2005-03-26 | 104.24d | 33.43d | 0d |  | 3110.82h | 13,936,464.49 | 13,936,464.49 |
| 21 | 2.3.1 | Hidroizolacija tlaka | 2.87d | 2004-12-23 | 2005-01-03 | 16FS+7d | 2004-12-23 | 2005-01-03 | 2.87d | 0d |  | Delavec [400%] | 109.2h | 1,241,149.43 | 1,241,149.43 |
| 22 | 2.3.2 | Zidanje sten | 20.65d | 2005-01-03 | 2005-01-28 | 21 | 2005-01-03 | 2005-01-28 | 20.65d | 0d |  | Delavec [350%] | 686.68h | 3,262,924.91 | 3,262,924.91 |
| 23 | 2.3.3 | Estrihi | 10.11d | 2005-03-15 | 2005-03-26 | 24FS+2d, 66SS+4d | 2005-03-15 | 2005-03-26 | 10.11d | 0d |  | Delavec [1350%] | 1297.13h | 5,611,060.34 | 5,611,060.34 |
| 24 | 2.3.4 | Ometi sten | 12.17d | 2005-02-10 | 2005-02-24 | 22FS+10d | 2005-02-10 | 2005-02-24 | 12.17d | 0d |  | Delavec [550%] | 635.74h | 2,993,637.51 | 2,993,637.51 |
| 25 | 2.3.5 | Hišna kanalizacija | 3.47d | 2004-11-13 | 2004-11-17 | 13FF-2d | 2004-11-13 | 2004-11-17 | 3.47d | 153.76d |  | Delavec [50%] | 16.5h | 90,250 | 90,250 |
| 26 | 2.3.6 | Vzidave, zidarske obdelave | 25.65d | 2005-01-28 | 2005-03-01 | 22 | 2005-01-28 | 2005-03-01 | 25.65d | 74.63d |  | Delavec [150%] | 365.57h | 737,442.3 | 737,442.3 |

| ID | WBS | Task | Duration | Start | Finish | Predecessors | Baseline start | Baseline finish | Baseline duration | Total slack | Free slack | Resources | Work | Cost | Baseline cost |
| --- | --- | --- | --- | --- | --- | --- | --- | --- | --- | --- | --- | --- | --- | --- | --- |
| 27 | 2.4 | **Tesarska dela** | 156.38d | 2004-10-04 | 2005-04-19 |  | 2004-10-04 | 2005-04-19 | 156.38d | 0d |  |  | 4216.48h | 11,294,985.22 | 11,294,985.22 |
| 28 | 2.4.1 | Opaž-Pasovni temelji | 10.95d | 2004-10-04 | 2004-10-16 | 9FS-2d | 2004-10-04 | 2004-10-16 | 10.95d | 0d |  | tesar [350%] | 364.1h | 766,001.76 | 766,001.76 |
| 29 | 2.4.2 | Opaž-Nastavki temeljev | 11.56d | 2004-10-11 | 2004-10-25 | 10SS+3d | 2004-10-11 | 2004-10-25 | 11.56d | 0d |  | tesar [750%] | 824h | 2,237,130.24 | 2,237,130.24 |
| 30 | 2.4.3 | Opaž-AB kinete | 7d | 2004-10-30 | 2004-11-09 | 11SS+3d | 2004-10-30 | 2004-11-09 | 7d | 0d |  |  |  |  |  |
| 31 | 2.4.4 | Opaž-Temeljna plošča | 3d | 2004-11-10 | 2004-11-15 | 12 | 2004-11-10 | 2004-11-15 | 3d | 0d |  |  |  |  |  |
| 32 | 2.4.5 | Opaž-Stene pritličje | 9.51d | 2004-11-23 | 2004-12-03 | 13FS+2d | 2004-11-23 | 2004-12-03 | 9.51d | 0d |  | tesar [400%] | 361.22h | 1,208,599.66 | 1,208,599.66 |
| 33 | 2.4.6 | Opaž-Dvigalni jašek | 10d | 2004-12-03 | 2004-12-16 | 32 | 2004-12-03 | 2004-12-16 | 10d | 169.21d | 0d |  |  |  |  |
| 34 | 2.4.7 | Opaž-Plošča I. Nadstropje | 6.95d | 2004-12-02 | 2004-12-10 | 14SS+5d | 2004-12-02 | 2004-12-10 | 6.95d | 0d |  | tesar [1050%] | 693.38h | 2,217,487.59 | 2,217,487.59 |
| 35 | 2.4.8 | Opaž-Stene,stene stebri I. Nadstropje | 4.04d | 2004-12-15 | 2004-12-20 | 16 | 2004-12-15 | 2004-12-20 | 4.04d | 116.94d | 0d | tesar [1100%] | 422.5h | 1,380,650.38 | 1,380,650.38 |
| 36 | 2.4.9 | Opaž-Plošča II. Nadstropje | 7.17d | 2004-12-21 | 2005-01-06 | 17 | 2004-12-21 | 2005-01-06 | 7.17d | 116.94d | 0d | tesar [1250%] | 851.46h | 2,142,070 | 2,142,070 |
| 37 | 2.4.10 | Opaž-Stopnišče | 3.52d | 2004-12-15 | 2004-12-20 | 16 | 2004-12-15 | 2004-12-20 | 3.52d | 161.79d | 0d | tesar | 33.48h | 67,408.96 | 67,408.96 |
| 38 | 2.4.11 | Fasadni odri | 28.06d | 2005-03-16 | 2005-04-19 | 68SS-5d | 2005-03-16 | 2005-04-19 | 28.06d | 74.01d | 0d | Delavec [250%] | 666.34h | 1,275,636.63 | 1,275,636.63 |
| 39 | 2.5 | **Pomožni objekt** | 19.58d | 2005-03-26 | 2005-04-19 |  | 2005-03-26 | 2005-04-19 | 19.58d | 74.38d |  |  | 179.2h | 1,686,296.35 | 1,686,296.35 |
| 40 | 2.5.1 | Groba gradnja | 12.58d | 2005-03-26 | 2005-04-11 | 20 | 2005-03-26 | 2005-04-11 | 12.58d | 74.38d | 0d | Delavec [150%] | 179.2h | 1,178,625.6 | 1,178,625.6 |
| 41 | 2.5.2 | Finalizacija-agrgat, smeti | 7d | 2005-04-11 | 2005-04-19 | 40 | 2005-04-11 | 2005-04-19 | 7d | 74.38d |  |  |  | 507,670.75 | 507,670.75 |
| 42 | 2.6 | **Kanalizacija** | 115.08d | 2004-11-11 | 2005-04-07 |  | 2004-11-11 | 2005-04-07 | 115.08d | 84.77d |  |  | 1851.22h | 8,312,835.81 | 8,312,835.81 |
| 43 | 2.6.1 | Priključni kanal | 4.32d | 2005-03-18 | 2005-03-23 | 20FS-7d | 2005-03-18 | 2005-03-23 | 4.32d | 53d | 0d | Delavec [200%] | 82.07h | 318,761.09 | 318,761.09 |
| 44 | 2.6.2 | Notranja kanalizacija | 5.13d | 2004-11-11 | 2004-11-17 | 13FF-2d | 2004-11-11 | 2004-11-17 | 5.13d | 194.72d |  | Delavec [800%] | 389.87h | 795,805.49 | 795,805.49 |
| 45 | 2.6.3 | Zunanja kanalizacija-fekalna | 4.9d | 2005-03-23 | 2005-03-29 | 43 | 2005-03-23 | 2005-03-29 | 4.9d | 53d | 0d | Delavec [900%] | 418.67h | 2,036,376.29 | 2,036,376.29 |
| 46 | 2.6.4 | Zunanja kanalizacija-meteorna | 6.97d | 2005-03-29 | 2005-04-07 | 45 | 2005-03-29 | 2005-04-07 | 6.97d | 53d | 0d | Delavec [1450%] | 960.61h | 5,161,892.92 | 5,161,892.92 |
| 47 | 2.7 | **Zunanja ureditev** | 27.77d | 2005-04-12 | 2005-05-18 |  | 2005-04-12 | 2005-05-18 | 27.77d | 53d |  |  | 1280.58h | 13,325,783.41 | 13,325,783.41 |
| 48 | 2.7.1 | Zemeljska dela, izkop, planum | 4.91d | 2005-04-12 | 2005-04-18 | 46FS+4d | 2005-04-12 | 2005-04-18 | 4.91d | 53d | 0d | Delavec [1600%] | 746.26h | 6,856,208.84 | 6,856,208.84 |
| 49 | 2.7.2 | Robni elementi, kanalete, jaški | 10.23d | 2005-04-18 | 2005-05-03 | 48 | 2005-04-18 | 2005-05-03 | 10.23d | 53d | 0d | Delavec [550%] | 534.32h | 1,348,780.98 | 1,348,780.98 |
| 50 | 2.7.3 | Asfalt | 4d | 2005-05-12 | 2005-05-17 | 52 | 2005-05-12 | 2005-05-17 | 4d | 53d | 0d |  |  | 3,650,099.5 | 3,650,099.5 |
| 51 | 2.7.4 | Oprema cest | 1.63d | 2005-05-17 | 2005-05-18 | 50 | 2005-05-17 | 2005-05-18 | 1.63d | 53d |  |  |  | 203,355.1 | 203,355.1 |
| 52 | 2.7.5 | Hortikulturna ureditev | 7d | 2005-05-03 | 2005-05-12 | 49 | 2005-05-03 | 2005-05-12 | 7d | 53d | 0d |  |  | 1,267,338.99 | 1,267,338.99 |

| ID | WBS | Task | Duration | Start | Finish | Predecessors | Baseline start | Baseline finish | Baseline duration | Total slack | Free slack | Cost | Baseline cost |
| --- | --- | --- | --- | --- | --- | --- | --- | --- | --- | --- | --- | --- | --- |
| 54 | 3 | **OBRTNIŠKA DELA** | 132.99d | 2005-01-20 | 2005-07-04 |  | 2005-01-20 | 2005-06-24 | 125.99d | 14.95d |  | 139,616,435.3 | 83,600,112.31 |
| 55 | 3.1 | Lesene konstrikcije | 7d | 2005-01-20 | 2005-01-28 | 18FS+7d | 2005-01-20 | 2005-01-28 | 7d | 116.94d | 0d | 10,464,346.84 | 10,464,346.84 |
| 56 | 3.2 | Krovska dela | 10d | 2005-01-28 | 2005-02-10 | 55 | 2005-01-28 | 2005-02-10 | 10d | 116.94d | 0d | 6,231,396.47 | 6,231,396.47 |
| 57 | 3.3 | Kleparska dela | 10d | 2005-02-15 | 2005-02-28 | 58 | 2005-02-15 | 2005-02-28 | 10d | 116.94d |  | 1,042,657.3 | 1,042,657.3 |
| 58 | 3.4 | Strešna okna, lopute | 4d | 2005-02-10 | 2005-02-15 | 56 | 2005-02-10 | 2005-02-15 | 4d | 116.94d | 0d | 244,150 | 244,150 |
| 59 | 3.5 | **Ključavničarska dela** | 32d | 2005-03-26 | 2005-05-07 |  | 2005-03-26 | 2005-05-07 | 32d | 61.95d |  | 4,117,722.76 | 4,117,722.76 |
| 60 | 3.5.1 | Ograje, ročaji | 7d | 2005-04-01 | 2005-04-11 | 23FS+5d | 2005-04-01 | 2005-04-11 | 7d | 81.95d |  | 1,409,243.3 | 1,409,243.3 |
| 61 | 3.5.2 | Drsna kovinska vrata | 5d | 2005-03-26 | 2005-04-01 | 23 | 2005-03-26 | 2005-04-01 | 5d | 83.95d | 0d | 1,147,600 | 1,147,600 |
| 62 | 3.5.3 | Dvižna vrata | 5d | 2005-04-01 | 2005-04-07 | 61 | 2005-04-01 | 2005-04-07 | 5d | 83.95d |  | 754,110 | 754,110 |
| 63 | 3.5.4 | WC kabine | 5d | 2005-05-02 | 2005-05-07 | 80FS+2d | 2005-05-02 | 2005-05-07 | 5d | 61.95d |  | 806,769.46 | 806,769.46 |
| 64 | 3.6 | **Okna, Vrata** | 57.11d | 2005-03-01 | 2005-05-11 |  | 2005-03-01 | 2005-05-11 | 57.11d | 0d |  | 15,304,376.5 | 15,304,376.5 |
| 65 | 3.6.1 | Obodne zasteklitve | 8d | 2005-03-01 | 2005-03-10 | 24FS+3d | 2005-03-01 | 2005-03-10 | 8d | 0d |  | 1,470,695 | 1,470,695 |
| 66 | 3.6.2 | Okna | 10d | 2005-03-10 | 2005-03-22 | 65 | 2005-03-10 | 2005-03-22 | 10d | 0d |  | 5,493,926 | 5,493,926 |
| 67 | 3.6.3 | Obrobe, alu police, senčila | 6d | 2005-03-31 | 2005-04-07 | 68 | 2005-03-31 | 2005-04-07 | 6d | 84.07d |  | 1,136,086 | 1,136,086 |
| 68 | 3.6.4 | Fasadni elementi | 8d | 2005-03-22 | 2005-03-31 | 66 | 2005-03-22 | 2005-03-31 | 8d | 84.07d | 0d | 4,544,344 | 4,544,344 |
| 69 | 3.6.5 | Notranje steklene stene | 5d | 2005-04-26 | 2005-05-05 | 82 | 2005-04-26 | 2005-05-05 | 5d | 58.95d | 0d | 1,682,640 | 1,682,640 |
| 70 | 3.6.6 | Alu vrata | 5d | 2005-05-05 | 2005-05-11 | 69 | 2005-05-05 | 2005-05-11 | 5d | 58.95d |  | 976,685.5 | 976,685.5 |
| 71 | 3.7 | Mizarska dela | 10d | 2005-05-28 | 2005-06-09 | 90 | 2005-05-28 | 2005-06-09 | 10d | 34.95d |  | 5,385,625.05 | 5,385,625.05 |
| 72 | 3.8 | **Fasaderska dela** | 22d | 2005-03-24 | 2005-04-20 |  | 2005-03-24 | 2005-04-20 | 22d | 74.01d |  | 18,316,329.62 | 18,316,329.62 |
| 73 | 3.8.1 | Tanakoslojna fasada | 14d | 2005-03-24 | 2005-04-11 | 66, 38FF-7d | 2005-03-24 | 2005-04-11 | 14d | 82.01d |  | 3,716,747.47 | 3,716,747.47 |
| 74 | 3.8.2 | Leseni del fasade | 12d | 2005-03-30 | 2005-04-14 | 38FF-4d | 2005-03-30 | 2005-04-14 | 12d | 74.01d | 0d | 8,292,704 | 8,292,704 |
| 75 | 3.8.3 | Zaključki | 5d | 2005-04-14 | 2005-04-20 | 74 | 2005-04-14 | 2005-04-20 | 5d | 74.01d |  | 6,306,878.15 | 6,306,878.15 |
| 76 | 3.9 | **Kamnoseška dela** | 8d | 2005-04-26 | 2005-05-09 |  | 2005-04-26 | 2005-05-09 | 8d | 60.95d |  | 1,368,557.65 | 1,368,557.65 |
| 77 | 3.9.1 | Tlaki | 5d | 2005-04-26 | 2005-05-05 | 80 | 2005-04-26 | 2005-05-05 | 5d | 60.95d | 0d | 549,195 | 549,195 |
| 78 | 3.9.2 | Portali | 3d | 2005-05-05 | 2005-05-09 | 77 | 2005-05-05 | 2005-05-09 | 3d | 60.95d |  | 179,196.6 | 179,196.6 |
| 79 | 3.9.3 | Okenske police | 3d | 2005-05-05 | 2005-05-09 | 77 | 2005-05-05 | 2005-05-09 | 3d | 60.95d |  | 640,166.05 | 640,166.05 |

| ID | WBS | Task | Duration | Start | Finish | Predecessors | Baseline start | Baseline finish | Baseline duration | Total slack | Free slack | Resources | Work | Cost | Baseline cost |
| --- | --- | --- | --- | --- | --- | --- | --- | --- | --- | --- | --- | --- | --- | --- | --- |
| 80 | 3.10 | **Keramičarska dela** | 20d | 2005-04-01 | 2005-04-26 |  | 2005-04-01 | 2005-04-26 | 20d | 58.95d | 0d |  |  | 4,656,422.12 | 4,656,422.12 |
| 81 | 3.10.1 | Stenska obloga | 10d | 2005-04-01 | 2005-04-14 | 23FS+5d | 2005-04-01 | 2005-04-14 | 10d | 58.95d | 0d |  |  | 2,738,522.87 | 2,738,522.87 |
| 82 | 3.10.2 | Tlaki2 | 10d | 2005-04-14 | 2005-04-26 | 81 | 2005-04-14 | 2005-04-26 | 10d | 58.95d | 0d |  |  | 1,917,899.25 | 1,917,899.25 |
| 83 | 3.11 | **Mavčarska dela** | 44d | 2005-04-19 | 2005-06-14 |  | 2005-04-19 | 2005-06-14 | 44d | 0d |  |  |  | 4,673,397.08 | 4,673,397.08 |
| 84 | 3.11.1 | Predelne stene | 10d | 2005-04-19 | 2005-05-04 | 89FF | 2005-04-19 | 2005-05-04 | 10d | 24.95d | 0d |  |  | 1,717,193.4 | 1,717,193.4 |
| 85 | 3.11.2 | Spuščeni stropovi | 14d | 2005-05-28 | 2005-06-14 | 90 | 2005-05-28 | 2005-06-14 | 14d | 0d |  |  |  | 2,956,203.68 | 2,956,203.68 |
| 86 | 3.12 | Montaža dvigala | 14d | 2005-04-07 | 2005-04-25 | 23FS+10d | 2005-04-07 | 2005-04-25 | 14d | 69.95d |  |  |  | 3,724,916.75 | 3,724,916.75 |
| 87 | 3.13 | Razna dela | 3d | 2005-05-28 | 2005-06-01 | 90 | 2005-05-28 | 2005-06-01 | 3d | 41.95d |  |  |  | 341,563 | 341,563 |
| 88 | 3.14 | **Slikopleskarska dela** | 67d | 2005-04-01 | 2005-06-24 |  | 2005-04-01 | 2005-06-24 | 67d | 0d |  |  |  | 1,904,900.63 | 1,904,900.63 |
| 89 | 3.14.1 | Kitanje sten in stropov | 24d | 2005-04-01 | 2005-05-04 | 23FS+5d, 24FS+20d | 2005-04-01 | 2005-05-04 | 24d | 0d |  |  |  | 520,682.17 | 520,682.17 |
| 90 | 3.14.2 | Slikanje ometanih sten,stropov | 20d | 2005-05-04 | 2005-05-28 | 89 | 2005-05-04 | 2005-05-28 | 20d | 0d |  |  |  | 909,487.6 | 909,487.6 |
| 91 | 3.14.3 | Slikanje knauf sten | 12d | 2005-05-13 | 2005-05-28 | 90FF | 2005-05-13 | 2005-05-28 | 12d | 44.95d |  |  |  | 474,730.86 | 474,730.86 |
| 92 | 3.14.4 | Slikopleskarska razna dela, popravila | 9d | 2005-06-14 | 2005-06-24 | 85 | 2005-06-14 | 2005-06-24 | 9d | 21.95d |  |  |  |  |  |
| 93 | 3.15 | Tlakarska dela | 15d | 2005-06-07 | 2005-06-24 | 85SS+8d | 2005-06-07 | 2005-06-24 | 15d | 0d |  |  |  | 5,823,750.54 | 5,823,750.54 |
| 94 | 3.16 | **STROJNE INSTALACIJE** | 100d | 2005-02-11 | 2005-06-15 |  | 2005-02-11 | 2005-06-15 | 100d | 24.95d |  |  |  | 31,853,682.22 | 31,853,682.22 |
| 95 | 3.16.1 | Groba montaža | 70d | 2005-02-11 | 2005-05-10 | 84FF+5d | 2005-02-11 | 2005-05-10 | 70d | 24.95d | 0d |  |  | 25,623,300.07 | 25,623,300.07 |
| 96 | 3.16.2 | Fina montaža | 20d | 2005-05-23 | 2005-06-15 | 95FS+10d | 2005-05-23 | 2005-06-15 | 20d | 29.95d |  |  |  | 6,230,382.15 | 6,230,382.15 |
| 97 | 3.17 | **ELEKTROINSTALACIJE** | 105d | 2005-02-11 | 2005-06-21 |  | 2005-02-11 | 2005-06-21 | 105d | 24.95d |  |  |  | 22,500,795.07 | 22,500,795.07 |
| 98 | 3.17.1 | Groba montaža2 | 80d | 2005-02-11 | 2005-05-23 | 95FF+10d | 2005-02-11 | 2005-05-23 | 80d | 24.95d | 0d |  |  | 21,998,495.47 | 21,998,495.47 |
| 99 | 3.17.2 | Fina montaža 2 | 20d | 2005-05-28 | 2005-06-21 | 98FS+5d | 2005-05-28 | 2005-06-21 | 20d | 24.95d |  |  |  | 502,299.6 | 502,299.6 |
| 101 | 3.18 | Finalizacija del | 7d | 2005-06-24 | 2005-07-04 | 93 | 2005-06-24 | 2005-07-04 | 7d | 0d |  |  |  | 1,661,845.7 |  |
| 102 | 4 | Finalno čiščenje | 3.95d | 2005-07-04 | 2005-07-08 | 101 | 2005-07-04 | 2005-07-08 | 3.95d | 0d |  | Delavec [900%] | 338.14h | 661,943.28 | 661,943.28 |
| 103 | 5 | Tehnični pregled | 1d | 2005-07-08 | 2005-07-09 | 102 | 2005-07-08 | 2005-07-09 | 1d | 0d |  |  |  |  |  |
| 104 | 6 | Oprava napak pred predajo objekta | 8d | 2005-07-09 | 2005-07-20 | 103 | 2005-07-09 | 2005-07-20 | 8d | 0d |  |  |  |  |  |
| 105 | 7 | Primopredaja objekta | 2d | 2005-07-20 | 2005-07-22 | 104 | 2005-07-20 | 2005-07-22 | 2d | 0d |  |  |  |  |  |
